# AL-02 - met grondverbetering

Schedule from MS Project, 2003-01-12 to 2003-01-26, status date 2003-01-08.
BAM Nelissen Van Egteren

## Calendars

- ALLEEN WERKDAGEN: Mon-Fri 08:30-12:30, 13:00-17:00; Sat-Sun off. Exceptions (off unless hours are given): 2003-01-11 to 2003-01-12 08:30-12:30, 13:00-17:00, 2003-01-18 to 2003-01-19 08:30-12:30, 13:00-17:00, 2003-01-25 to 2003-01-26 08:30-12:30, 13:00-17:00.

## Schedule

| ID | WBS | Task | Type | Duration | Start | Finish | Predecessors | Total slack |
| --- | --- | --- | --- | --- | --- | --- | --- | --- |
| 1 | 1 | **AANLOOPFASE** |  | 15d | 2003-01-12 | 2003-01-26 |  | 0d |
| 2 | 1.1 | keten/loodsen/afrastering |  | 5d | 2003-01-12 | 2003-01-16 |  | 0d |
| 3 | 1.2 | bouwinstallatie aanleggen |  | 5d | 2003-01-12 | 2003-01-16 | 2SS | 0d |
| 4 | 1.3 | bouwwegen aanleggen |  | 5d | 2003-01-13 | 2003-01-17 | 3SS+1d | 0d |
| 5 | 1.4 | uitzetten+bouwplanken |  | 2d | 2003-01-16 | 2003-01-17 | 4SS+3d | 0d |
| 6 | 1.5 | bouwput ontgraven |  | 5d | 2003-01-18 | 2003-01-22 | 5SS+2d | 0d |
| 7 | 1.6 | grondverbetering aanbrengen |  | 5d | 2003-01-21 | 2003-01-25 | 6SS+3d | 0d |
| 8 | 1.7 | aanvulling zand aftrillen |  | 4d | 2003-01-23 | 2003-01-26 | 7SS+2d | 0d |
| 9 | 1.8 | maatvoeren funderingsbalken |  | 1d | 2003-01-26 | 2003-01-26 | 8SS+3d | 0d |
| 10 | 1.9 | start onderbouw | milestone | 0d | 2003-01-26 | 2003-01-26 | 9SS+1d | 0d |
